# Projekt_jo_02_03

Schedule from MS Project, 2008-10-27 to 2009-05-21, status date 2008-08-29, costs in Ft.
iqjb

## Calendars

- Szabványos: Mon-Fri 08:00-12:00, 13:00-17:00; Sat-Sun off.

## Resources

| Resource | Unit | Rate |
| --- | --- | --- |
| Á hálózatépítő 1 |  | 1500 |
| Á műszaki informatikus 1 |  | 1500 |
| Á adminisztrátor 1 |  | 1000 |
| Kovács Anita |  | 6000 |
| Kiss Attila |  | 10000 |
| Nagy Annamária |  | 1200 |
| Paál Anikó |  | 1300 |
| Kiss Anett |  | 800 |
| Rétlaki Géza |  | 1400 |
| Mároki Teréz |  | 1400 |
| Mosolygó Ferenc |  | 1600 |
| Téglás Csaba |  | 1200 |
| Podorek Paula |  | 800 |
| Tiefenghalter Eszter |  | 1200 |
| Szakócza István |  | 1700 |
| Késmárki Lilla |  | 1500 |
| Á hálózatépítő 2 |  | 1500 |
| Á műszaki informatikus 2 |  | 1500 |
| Á adminisztrátor 2 |  | 1000 |
| Á műszaki informatikus 3 |  | 1500 |
| Á adminisztrátor 3 |  | 1000 |
| Á adminisztrátor 4 |  | 1000 |
| Számítógép beszerzési költségek | eFt | 1000 |
| Hálózatépítés költségei | eFt | 1000 |
| Egyéb költségek | eFt | 1000 |
| Szoftverköltségek | eFt | 1000 |
| Á programozó 3 |  | 6000 |
| Á programozó 4 |  | 6000 |
| Á_projektszponzor |  | 8000 |
| Á oktató 1 |  | 4000 |
| Á oktató 2 |  | 4000 |
| Á oktató 3 |  | 4000 |
| Á műszaki informatikus 4 |  | 1500 |
| Kő Pál |  | 1200 |
| Kiss Irén |  | 1200 |
| Nagy Armand |  | 1200 |
| Beke Botond |  | 1200 |
| Kőváry Laura |  | 1200 |
| Kőpataki Tihamér |  | 2100 |
| Baumgartner Karina |  |  |
| Mathiugasz Gitisz |  | 6000 |
| Oktatók |  |  |
| Műszaki szakemberek |  |  |
| Telepítési csoport |  |  |
| Á programozó 1 |  | 6000 |
| Á programozó 2 |  | 6000 |
| Á_projektmenedzser |  | 6000 |
| Á megbízó koordinátor 1 |  | 2500 |
| Á megbízó koordinátor 2 |  | 2500 |
| Kiss Edit |  | 7000 |
| Molnár Noémi |  | 7000 |

## Schedule

| ID | WBS | Task | Type | Duration | Start | Finish | Predecessors | Total slack | Free slack | Resources | Work | Cost | Text29 | nap, óra |
| --- | --- | --- | --- | --- | --- | --- | --- | --- | --- | --- | --- | --- | --- | --- |
| 1 | 1 | **Célmeghatározás** |  | 7.5d | 2008-10-27 | 2008-11-05 |  | 0d |  |  | 548h | 2,196,000 | 480 | 7 n, 4 ó |
| 2 | 1.1 | Projektindító értekezlet |  | 1d | 2008-10-27 | 2008-10-27 |  | 141d | 0d | Á műszaki informatikus 1; Á műszaki informatikus 2; Á műszaki informatikus 3; Á műszaki informatikus 4; Á programozó 1; Á programozó 2; Á programozó 3; Á programozó 4; Á_projektszponzor; Á_projektmenedzser | 80h | 352,000 | 480 | 1 n |
| 3 | 1.2 | Tárolandó dokumentumtípusok megismerése |  | 3d | 2008-10-28 | 2008-10-30 | 2 | 142d | 0d | Á műszaki informatikus 1; Á műszaki informatikus 3; Á programozó 1; Á programozó 2; Á programozó 3; Á programozó 4 | 144h | 648,000 | 480 | 3 n |
| 4 | 1.3 | Jelenlegi dokumentumkezelési eljárások megismerése |  | 2d | 2008-10-31 | 2008-11-03 | 3 | 142d | 1d | Á műszaki informatikus 1; Á műszaki informatikus 3; Á programozó 1; Á programozó 2; Á programozó 3; Á programozó 4 | 96h | 432,000 | 480 | 2 n |
| 5 | 1.4 | Az új rendszerrel szemben támasztott követelmények összeállítása |  | 6d | 2008-10-28 | 2008-11-04 | 2 | 141d | 0d | Á megbízó koordinátor 1; Á megbízó koordinátor 2 | 96h | 240,000 | 480 | 6 n |
| 6 | 1.5 | Megbízó oldali céldokumentum kész | milestone | 0d | 2008-11-04 | 2008-11-04 | 5 | 141d | 0d |  |  |  | 480 | --mérföldkő-- |
| 7 | 1.6 | Eredmények ismertetése |  | 4h | 2008-11-05 | 2008-11-05 | 6, 4 | 141d |  | Á megbízó koordinátor 1; Á műszaki informatikus 1; Á műszaki informatikus 3; Á programozó 1; Á programozó 2; Á programozó 3; Á programozó 4 | 28h | 118,000 | 480 | 4 ó |
| 8 | 1.7 | Az IT oldal javaslata az új rendszer specifikációjához |  | 4d | 2008-10-27 | 2008-10-30 |  | 144.5d |  | Á műszaki informatikus 3; Á programozó 1 | 64h | 240,000 | 480 | 4 n |
| 9 | 1.8 | IT oldali céldokumentum megvitatása |  | 4h | 2008-10-27 | 2008-10-27 |  | 0d |  | Á műszaki informatikus 3; Á programozó 1; Á megbízó koordinátor 1; Á megbízó koordinátor 2; Kiss Edit; Molnár Noémi | 24h | 106,000 | 480 | 4 ó |
| 10 | 1.9 | Módosítások elkészítése |  | 1d | 2008-10-27 | 2008-10-28 | 9 | 0d |  | Á programozó 1; Á műszaki informatikus 3 | 16h | 60,000 | 480 | 1 n |
| 11 | 1.10 | Céldokumentum elfogadása | milestone | 0d | 2008-10-28 | 2008-10-28 | 10 | 0d |  |  |  |  | 480 | --mérföldkő-- |
| 12 | 2 | **Tervezés** |  | 13d | 2008-10-28 | 2008-11-14 |  | 0d |  |  | 256h | 540,000 | 480 | 13 n |
| 13 | 2.1 | Üzemeltetési jellemzők kidolgozása |  | 6d | 2008-10-28 | 2008-11-05 | 11 | 0d |  | Á műszaki informatikus 1; Á műszaki informatikus 3 | 96h | 144,000 | 480 | 6 n |
| 14 | 2.2 | Prototípus kidolgozása az üzemeltetési jellemzők alapján |  | 4d | 2008-11-05 | 2008-11-11 | 13 | 0d |  | Á műszaki informatikus 1; Á műszaki informatikus 3 | 64h | 96,000 | 480 | 4 n |
| 15 | 2.3 | Funkcionális specifikációk áttekintése |  | 3d | 2008-11-11 | 2008-11-14 | 14 | 0d |  | Á műszaki informatikus 1; Á megbízó koordinátor 1; Á megbízó koordinátor 2; Á_projektmenedzser | 96h | 300,000 | 480 | 3 n |
| 16 | 2.4 | Döntés a továbblépésről | milestone | 0d | 2008-11-14 | 2008-11-14 | 15 | 0d |  | Á_projektszponzor |  |  | 480 | --mérföldkő-- |
| 17 | 2.5 | Tervezés kész | milestone | 0d | 2008-11-14 | 2008-11-14 | 16 | 0d |  |  |  |  | 480 | --mérföldkő-- |
| 18 | 3 | **Fejlesztés** |  | 26d | 2008-11-14 | 2008-12-22 |  | 0d |  |  | 832h | 4,992,000 | 480 | 26 n |
| 19 | 3.1 | Fejlesztés |  | 26d | 2008-11-14 | 2008-12-22 | 17 | 0d |  | Á programozó 1; Á programozó 2; Á programozó 3; Á programozó 4 | 832h | 4,992,000 | 480 | 26 n |
| 20 | 4 | **Tesztelés** |  | 60d | 2008-11-14 | 2009-02-06 |  | 0d |  |  | 2400h | 7,200,000 | 480 | 60 n |
| 21 | 4.1 | Tesztelés |  | 60d | 2008-11-14 | 2009-02-06 | 19SS | 0d |  | Á műszaki informatikus 2; Á műszaki informatikus 4; Á oktató 1; Á oktató 2; Á oktató 3 | 2400h | 7,200,000 | 480 | 60 n |
| 22 | 5 | **Dokumentáció** |  | 25d | 2009-01-21 | 2009-02-25 |  | 31d |  |  | 800h | 4,000,000 |  | 25 n |
| 23 | 5.1 | Dokumentáció készítése |  | 25d | 2009-01-21 | 2009-02-25 | 21FS-12d, 19 | 31d |  | Á programozó 1; Á programozó 2; Á oktató 1; Á oktató 2 | 800h | 4,000,000 | 480 | 25 n |
| 24 | 6 | **Próba** |  | 40d | 2009-02-06 | 2009-04-03 |  | 0d |  |  | 1280h | 3,520,000 |  | 40 n |
| 25 | 6.1 | Próbaüzem |  | 40d | 2009-02-06 | 2009-04-03 | 21 | 0d |  | Á műszaki informatikus 2; Á műszaki informatikus 3; Á oktató 1; Á oktató 2 | 1280h | 3,520,000 | 480 | 40 n |

| ID | WBS | Task | Duration | Start | Finish | Predecessors | Total slack | Resources | Work | Cost | Text29 | nap, óra |
| --- | --- | --- | --- | --- | --- | --- | --- | --- | --- | --- | --- | --- |
| 26 | 7 | **Telepítés** | 4d | 2009-04-03 | 2009-04-09 |  | 0d |  | 64h | 96,000 | 480 | 4 n |
| 27 | 7.1 | Telepítés | 4d | 2009-04-03 | 2009-04-09 | 25 | 0d | Á műszaki informatikus 1; Á műszaki informatikus 2 | 64h | 96,000 | 480 | 4 n |
| 28 | 8 | **Továbbképzés** | 30d | 2009-04-09 | 2009-05-21 |  | 0d |  | 744h | 2,916,000 | 480 | 30 n |
| 29 | 8.1 | Továbbképzés | 30d | 2009-04-09 | 2009-05-21 | 27, 23 | 0d | Á oktató 1; Á oktató 2; Á oktató 3; Á műszaki informatikus 2 [10%] | 744h | 2,916,000 | 480 | 30 n |
